# TurbulenceSchedule

Schedule from MS Project, 2021-01-21 to 2022-04-20.
MBARI

## Calendars

- Standard: Mon-Fri 08:00-12:00, 13:00-17:00; Sat-Sun off.

## Schedule

| ID | WBS | Task | Type | Duration | Start | Finish | Predecessors | Total slack | Free slack | Constraint |
| --- | --- | --- | --- | --- | --- | --- | --- | --- | --- | --- |
| 1 | 1 | **Turbulence Project** |  | 325d? | 2021-01-21 | 2022-04-20 |  | 0d |  |  |
| 2 | 1.1 | MBARI open for req'd staff | milestone, manual | 0d | 2021-03-01 | 2021-03-01 |  |  |  |  |
| 3 | 1.2 | **CPF** |  | 77d? | 2021-01-21 | 2021-05-07 |  | 72d |  |  |
| 4 | 1.2.1 | **Mechanical** |  | 33d? | 2021-01-21 | 2021-03-08 |  | 292d |  |  |
| 5 | 1.2.1.1 | Get Paul/Mike Started |  | 1d? | 2021-01-21 | 2021-01-21 |  | 308d | 0d |  |
| 6 | 1.2.1.2 | Bracket design |  | 10d | 2021-01-22 | 2021-02-04 | 5 | 308d | 16d |  |
| 7 | 1.2.1.3 | Bracket build |  | 5d | 2021-03-01 | 2021-03-05 | 6, 2 | 292d | 0d |  |
| 8 | 1.2.1.4 | Bracket test fit |  | 1d | 2021-03-08 | 2021-03-08 | 7 | 292d |  |  |
| 9 | 1.2.2 | Finish Turbulence CPF | milestone, manual | 0d | 2021-05-03 | 2021-05-03 | 2FS+45d |  |  |  |
| 10 | 1.2.3 | **Software** |  | 60d | 2021-02-15 | 2021-05-07 |  | 248d |  |  |
| 11 | 1.2.3.1 | Modify software for new science mission |  | 10d | 2021-02-15 | 2021-02-26 | 15 | 293d | 45d |  |
| 12 | 1.2.3.2 | Test on benchtop simulator and test tank |  | 5d | 2021-05-03 | 2021-05-07 | 11, 2, 9 | 248d |  |  |
| 13 | 1.3 | **Science** |  | 5d | 2021-02-15 | 2021-02-22 |  | 5d |  |  |
| 14 | 1.3.1 | Place Microrider PO | milestone, manual | 0d | 2021-02-22 | 2021-02-22 |  |  |  | start no earlier than 2021-02-22 |
| 15 | 1.3.2 | Mission plan first draft | milestone | 0d | 2021-02-15 | 2021-02-15 |  | 293d | 0d | start no earlier than 2021-02-15 |
| 16 | 1.4 | Microrider arrives | milestone, manual | 0d | 2021-06-07 | 2021-06-07 |  |  |  | start no earlier than 2021-06-07 |
| 17 | 1.5 | Ship Microrider back | milestone, manual | 0d | 2021-07-07 | 2021-07-07 | 16FS+22d |  |  |  |
| 18 | 1.6 | **Integration** |  | 14d | 2021-06-07 | 2021-06-24 |  | 0d |  |  |
| 19 | 1.6.1 | Bolt it all together |  | 1d | 2021-06-07 | 2021-06-07 | 16 | 0d |  |  |
| 20 | 1.6.2 | Stability tests |  | 2d | 2021-06-08 | 2021-06-09 | 19 | 0d |  |  |
| 21 | 1.6.3 | Run short missions in tank |  | 3d | 2021-06-10 | 2021-06-14 | 20 | 0d |  |  |
| 22 | 1.6.4 | Analyze data |  | 1d | 2021-06-15 | 2021-06-15 | 21 | 0d |  |  |
| 23 | 1.6.5 | Run longer mission in tank |  | 3d | 2021-06-16 | 2021-06-18 | 22 | 0d |  |  |
| 24 | 1.6.6 | Analyze data |  | 1d | 2021-06-21 | 2021-06-21 | 23 | 0d |  |  |
| 25 | 1.6.7 | Maybe re-run longer mission in tank |  | 3d | 2021-06-22 | 2021-06-24 | 24 | 0d |  |  |

| ID | WBS | Task | Type | Duration | Start | Finish | Predecessors | Total slack |
| --- | --- | --- | --- | --- | --- | --- | --- | --- |
| 26 | 1.7 | **At sea tests** |  | 60d | 2021-05-03 | 2021-07-23 |  | 0d |
| 27 | 1.7.1 | Prerun science mission |  | 2d | 2021-05-03 | 2021-05-04 | 9 | 37d |
| 28 | 1.7.2 | 1 day mission #1 |  | 1d | 2021-06-25 | 2021-06-25 | 25, 27 | 0d |
| 29 | 1.7.3 | Analyze data and modify mission profile as req'd |  | 1d | 2021-06-28 | 2021-06-28 | 28 | 0d |
| 30 | 1.7.4 | 1 day mission #2 |  | 1d | 2021-06-29 | 2021-06-29 | 29 | 0d |
| 31 | 1.7.5 | Analyze data and modify mission profile as req'd |  | 1d | 2021-06-30 | 2021-06-30 | 30 | 0d |
| 32 | 1.7.6 | Full mission #1 |  | 5d | 2021-07-01 | 2021-07-07 | 31 | 0d |
| 33 | 1.7.7 | Analyze data and modify mission profile as req'd |  | 2d | 2021-07-08 | 2021-07-09 | 32 | 0d |
| 34 | 1.7.8 | Full mission #2 |  | 10d | 2021-07-12 | 2021-07-23 | 33 | 0d |
| 35 | 1.8 | Write and publish papers |  | 8d | 2021-07-26 | 2021-08-04 | 34 | 0d |
| 36 | 1.9 | Accept Nobel Peace Prize | manual | 5d | 2022-04-14 | 2022-04-20 | 35FS+180d |  |
